# CSM opgaver Pernille

Schedule from MS Project, 2025-08-22 to 2026-12-11.

## Calendars

- Standard: Mon-Fri 08:00-12:00, 13:00-17:00; Sat-Sun off.

## Resources

| Resource |
| --- |
| COWI? |
| Rambøll |
| TOEL |
| PEMO |
| Sweco |
| ? |
| COWI |
| AFRY |
| Atkins |
| Møller-Lassen |
| Ansøger |
| PRO |
| LT PRO |
| LT SIK |
| LT TSA |
| 3.part |
| LT TRA |

## Schedule

| ID | WBS | Task | Type | Duration | Start | Finish | Predecessors | Total slack | Free slack | Constraint | Resources | Work |
| --- | --- | --- | --- | --- | --- | --- | --- | --- | --- | --- | --- | --- |
| 1 | 1 | **Projekttitel: Projektnummer + navn** |  | 341d | 2025-08-22 | 2026-12-11 |  | 0d |  |  |  | 3760h |
| 2 | 1.1 | **Projektdokumenter** |  | 66d | 2025-08-22 | 2025-11-21 |  | 0d |  |  |  | 528h |
| 3 | 1.1.1 | Fremsendelse af Projektdokumenter til Lokaltog via hjemmesiden, jf. Dokumentoversigten |  | 1d | 2025-08-22 | 2025-08-22 |  | 0d |  | start no earlier than 2025-08-22 | 3.part | 8h |
| 4 | 1.1.2 | 1. Review hos Lokaltogs 3.parts projektleder. |  | 15d | 2025-08-25 | 2025-09-12 | 3 | 0d |  |  | LT PRO | 120h |
| 5 | 1.1.3 | Opdatering iht. LT PRO kommentarer |  | 10d | 2025-09-15 | 2025-09-26 | 4 | 0d |  |  | 3.part | 80h |
| 6 | 1.1.4 | 2. Review hos Lokaltogs 3.parts projektleder. |  | 15d | 2025-09-29 | 2025-10-17 | 5 | 0d |  |  | LT PRO | 120h |
| 7 | 1.1.5 | Opdatering iht. LT PRO kommentarer |  | 10d | 2025-10-20 | 2025-10-31 | 6 | 0d |  |  | 3.part | 80h |
| 8 | 1.1.6 | 3.parts PL fremsender godkendelse af Projektdokumenter til 3.part |  | 15d | 2025-11-03 | 2025-11-21 | 7 | 0d |  |  | LT TSA | 120h |
| 9 | 1.2 | **Faglig Ledelse** |  | 111d | 2025-11-24 | 2026-04-27 |  | -15d | 0d |  |  | 888h |
| 10 | 1.2.1 | Fremsendelse af dokumenter til Faglig Ledelse til Lokaltogs 3.parts PL, jf. Dokumentoversigten |  | 1d | 2025-11-24 | 2025-11-24 | 8 | 0d |  | start no earlier than 2025-08-22 | 3.part | 8h |
| 11 | 1.2.2 | 1. Review hos Lokaltogs 3.parts PL | manual | 15d | 2025-11-25 | 2025-12-15 | 10 |  |  |  | LT PRO | 120h |
| 12 | 1.2.3 | 1. Faglig Ledelse hos Lokaltogs Teknisk System Ansvarlige (TSA) |  | 15d | 2025-12-16 | 2026-01-05 | 11 | 0d |  |  | LT TSA | 120h |
| 13 | 1.2.4 | Opdatering iht. LT TSA kommentarer |  | 10d | 2026-01-06 | 2026-01-19 | 12 | 0d |  |  | 3.part | 80h |
| 14 | 1.2.5 | 2. Review hos Lokaltogs 3.parts PL | manual | 15d | 2026-01-20 | 2026-02-09 | 13 |  |  |  | LT PRO | 120h |
| 15 | 1.2.6 | 2. Faglig Ledelse hos Lokaltogs TSA |  | 15d | 2026-02-10 | 2026-03-02 | 14 | 0d |  |  | LT TSA | 120h |
| 16 | 1.2.7 | Opdatering iht. LT TSA kommentarer | manual | 10d | 2026-03-03 | 2026-03-16 | 15 |  |  |  | 3.part | 80h |
| 17 | 1.2.8 | TSA godkender Faglig Ledelse | manual | 15d | 2026-03-17 | 2026-04-06 | 16 |  |  |  | LT TSA | 120h |
| 18 | 1.2.9 | 3.parts PL fremsender godkendelse af Faglig Ledelse til 3.part |  | 15d | 2026-04-07 | 2026-04-27 | 17 | -73d | 0d |  | LT PRO | 120h |
| 19 | 1.3 | **Sikkerhedspakke** |  | 116d | 2026-04-28 | 2026-10-06 |  | -73d | 0d |  |  | 1664h |
| 20 | 1.3.1 | Fremsendelse af Sikkerhedspakke til Lokaltogs 3.parts PL, jf. Dokumentoversigten |  | 1d | 2026-04-28 | 2026-04-28 | 18 | -73d | 0d |  | 3.part | 8h |
| 21 | 1.3.2 | 1. Review hos Lokaltogs CSM ansvarlige |  | 15d | 2026-04-29 | 2026-05-19 | 20 | -73d | 0d |  | LT PRO | 120h |
| 22 | 1.3.3 | Opdatering iht. LT PRO kommentarer |  | 10d | 2026-05-20 | 2026-06-02 | 21 | -73d | 0d |  | 3.part | 80h |
| 23 | 1.3.4 | 2. Review hos Lokaltogs CSM ansvarlige |  | 15d | 2026-06-03 | 2026-06-23 | 22 | -73d | 0d |  | LT PRO | 120h |
| 24 | 1.3.5 | Opdatering iht. LT PRO kommentarer |  | 10d | 2026-06-24 | 2026-07-07 | 23 | -73d | 0d |  | 3.part | 80h |
| 25 | 1.3.6 | Lokaltogs CSM ansvarlige godkender Sikkerhedspakke og sender den til LT Sikkerhed for udstedelse af IBTK |  | 15d | 2026-07-08 | 2026-07-28 | 24 | -73d | 0d |  | LT PRO | 120h |
| 26 | 1.3.7 | 1. Behandling hos Lokaltog Sikkerhed |  | 15d | 2026-07-29 | 2026-08-18 | 25 | -73d | 0d |  | LT SIK | 120h |
| 27 | 1.3.8 | Opdatering iht. LT SIK kommentarer |  | 10d | 2026-08-19 | 2026-09-01 | 26 | -73d | 0d |  | 3.part | 80h |
| 28 | 1.3.9 | 2. Behandling hos Lokaltog Sikkerhed |  | 15d | 2026-09-02 | 2026-09-22 | 27 | -73d | 0d |  | LT SIK | 120h |
| 29 | 1.3.10 | Opdatering iht. LT SIK kommentarer | manual | 10d | 2026-06-12 | 2026-06-25 | 28 |  |  |  | 3.part | 80h |
| 30 | 1.3.11 | LT Sikkerhed udsteder Ibrugtagningstilkendegivelse og sender til LT CSM ansvarlig |  | 15d | 2026-06-26 | 2026-07-16 | 29 | 0d |  |  | LT SIK | 120h |
| 31 | 1.3.12 | LT 3.parts projektleder fremsender IBTK til 3.part | manual | 15d | 2026-07-17 | 2026-08-06 | 30 |  |  |  | LT PRO | 120h |
| 32 | 1.3.13 | Udførelse | manual | 1d? | 2026-04-28 | 2026-04-28 |  |  |  |  |  |  |
| 33 | 1.3.14 | Fremsendelse af Jernbanesikkerhedsplan/ Sporspærringscirkulære/ LA-formular til Lokaltogs 3.parts PL | manual | 1d | 2026-08-07 | 2026-08-07 | 31 |  |  |  | 3.part | 8h |
| 34 | 1.3.15 | 1. Review hos Lokaltogs 3. parts PL | manual | 15d | 2026-08-10 | 2026-08-28 | 33 |  |  |  | LT PRO | 120h |
| 35 | 1.3.16 | Opdatering iht. LT PRO kommentarer | manual | 10d | 2026-08-31 | 2026-09-11 | 34 |  |  |  | 3.part | 80h |
| 36 | 1.3.17 | Lokaltogs 3.parts projektleder godkender og sender til godkendelse hos Trafik | manual | 15d | 2026-09-07 | 2026-09-25 | 35 |  |  |  | LT PRO | 120h |
| 37 | 1.3.18 | Trafik godkender Jernbanesikkerhedsplan/ Sporspærringscirkulære/ LA-formular | manual | 15d | 2026-09-08 | 2026-09-28 | 36 |  |  |  | LT TRA | 120h |
| 38 | 1.3.19 | Udførelse |  | 5d | 2026-09-29 | 2026-10-05 | 37 | -37d | 0d | finish no earlier than 2023-09-22 | 3.part | 40h |
| 39 | 1.3.20 | Ibrugtaning |  | 1d | 2026-10-06 | 2026-10-06 | 38 | -37d | 0d |  | 3.part | 8h |

| ID | WBS | Task | Type | Duration | Start | Finish | Predecessors | Total slack | Free slack | Resources | Work |
| --- | --- | --- | --- | --- | --- | --- | --- | --- | --- | --- | --- |
| 40 | 1.4 | **Tillæg 1 (6uger fra ibrugtagning til LT Sikkerhed)** |  | 60d | 2026-09-21 | 2026-12-11 |  | -25d | 0d |  | 680h |
| 41 | 1.4.1 | Udarbejdelse af Tillæg 1 herunder opdatering af Sikkerhedsdokumentationen. |  | 10d | 2026-10-07 | 2026-10-20 | 39 | -37d | 0d | 3.part | 80h |
| 42 | 1.4.2 | 1. Review hos Lokaltog CSM ansvarlige |  | 10d | 2026-10-21 | 2026-11-03 | 41 | -37d | 0d | LT PRO | 80h |
| 43 | 1.4.3 | Opdatering iht. LT PRO kommentarer |  | 5d | 2026-11-04 | 2026-11-10 | 42 | -37d | 0d | 3.part | 40h |
| 44 | 1.4.4 | Lokaltogs CSM ansvarlige godkender Tillæg 1 og sender den til LT Sikkerhed til godkendelse | manual | 5d | 2026-09-21 | 2026-09-25 | 43 |  |  | LT PRO | 40h |
| 45 | 1.4.5 | 1. Behandling hos Lokaltog Sikkerhed |  | 15d | 2026-09-28 | 2026-10-16 | 44 | 0d |  | LT SIK | 120h |
| 46 | 1.4.6 | Opdatering iht. LT SIK kommentarer |  | 10d | 2026-10-19 | 2026-10-30 | 45 | 0d |  | 3.part | 80h |
| 47 | 1.4.7 | LT Sikkerhed godkender Tillæg 1 og sender til LT CSM ansvarlig |  | 15d | 2026-11-02 | 2026-11-20 | 46 | 0d |  | LT SIK | 120h |
| 48 | 1.4.8 | LT 3.parts projektleder fremsender godkendelse af Tillæg 1 til 3.part |  | 15d | 2026-11-23 | 2026-12-11 | 47 | 0d |  | LT PRO | 120h |
